# AB-05 - met stuc+tegelwerk

Schedule from MS Project, 2003-01-12 to 2003-02-20, status date 2003-01-08.
BAM Nelissen Van Egteren

## Calendars

- ALLEEN WERKDAGEN: Mon-Fri 08:30-12:30, 13:00-17:00; Sat-Sun off. Exceptions (off unless hours are given): 2003-01-11 to 2003-01-12 08:30-12:30, 13:00-17:00, 2003-01-18 to 2003-01-19 08:30-12:30, 13:00-17:00, 2003-01-25 to 2003-01-26 08:30-12:30, 13:00-17:00, 2003-02-01 to 2003-02-02 08:30-12:30, 13:00-17:00, 2003-02-08 to 2003-02-09 08:30-12:30, 13:00-17:00, 2003-02-15 to 2003-02-16 08:30-12:30, 13:00-17:00.

## Schedule

| ID | WBS | Task | Type | Duration | Start | Finish | Predecessors | Total slack |
| --- | --- | --- | --- | --- | --- | --- | --- | --- |
| 1 | 1 | **AFBOUWFASE** |  | 40d | 2003-01-12 | 2003-02-20 |  | 0d |
| 2 | 1.1 | **inbouwfase** |  | 18d | 2003-01-12 | 2003-01-29 |  | 0d |
| 3 | 1.1.1 | plafondleidingen vooraf | milestone | 0d | 2003-01-12 | 2003-01-12 |  | 40d |
| 4 | 1.1.2 | cementdekvloer aanbrengen |  | 4d | 2003-01-12 | 2003-01-15 |  | 0d |
| 5 | 1.1.3 | deurkozijnen+profielen stellen |  | 3d | 2003-01-16 | 2003-01-18 | 4SS+4d | 0d |
| 6 | 1.1.4 | binnenwanden metselen |  | 5d | 2003-01-19 | 2003-01-23 | 5SS+3d | 0d |
| 7 | 1.1.5 | plafondconstructie aanbr. |  | 5d | 2003-01-21 | 2003-01-25 | 6SS+2d | 0d |
| 8 | 1.1.6 | binnenwand sleuven fraisen |  | 5d | 2003-01-23 | 2003-01-27 | 7SS+2d | 0d |
| 9 | 1.1.7 | electra dozen+leidingen |  | 5d | 2003-01-25 | 2003-01-29 | 8SS+2d | 0d |
| 10 | 1.2 | **afwerkingsfase** |  | 15d | 2003-01-27 | 2003-02-10 |  | 0d |
| 11 | 1.2.1 | binnenwanden tegelwerk |  | 5d | 2003-01-27 | 2003-01-31 | 9SS+2d | 0d |
| 12 | 1.2.2 | binnenwanden stucwerk |  | 5d | 2003-01-29 | 2003-02-02 | 11SS+2d | 0d |
| 13 | 1.2.3 | plafondplaten inleggen |  | 5d | 2003-01-31 | 2003-02-04 | 12SS+2d | 0d |
| 14 | 1.2.4 | binnenwanden afwerken |  | 5d | 2003-02-02 | 2003-02-06 | 13SS+2d | 0d |
| 15 | 1.2.5 | harde vloerbedekking |  | 5d | 2003-02-04 | 2003-02-08 | 14SS+2d | 0d |
| 16 | 1.2.6 | zachte vloerbedekking |  | 5d | 2003-02-06 | 2003-02-10 | 15SS+2d | 0d |
| 17 | 1.3 | **uitrustingsfase** |  | 8d | 2003-02-07 | 2003-02-14 |  | 0d |
| 18 | 1.3.1 | binnendeuren afhangen |  | 5d | 2003-02-07 | 2003-02-11 | 16SS+1d | 0d |
| 19 | 1.3.2 | bouwkundige afmontage |  | 5d | 2003-02-08 | 2003-02-12 | 18SS+1d | 0d |
| 20 | 1.3.3 | electra afmontage |  | 5d | 2003-02-09 | 2003-02-13 | 19SS+1d | 0d |
| 21 | 1.3.4 | werktuigkundige afmontage |  | 5d | 2003-02-10 | 2003-02-14 | 20SS+1d | 0d |
| 22 | 1.3.5 | hang+sluitwerk afmonteren |  | 3d | 2003-02-11 | 2003-02-13 | 21SS+1d | 0d |
| 23 | 1.4 | **opleveringsfase** |  | 8d | 2003-02-13 | 2003-02-20 |  | 0d |
| 24 | 1.4.1 | vooropnemen afbouw |  | 5d | 2003-02-13 | 2003-02-17 | 22SS+2d | 0d |
| 25 | 1.4.2 | herstelwerkzaamheden |  | 5d | 2003-02-16 | 2003-02-20 | 24SS+3d | 0d |
| 26 | 1.4.3 | opleveren bouwlaag | milestone | 0d | 2003-02-20 | 2003-02-20 | 25SS+5d | 0d |
